Schedule from MS Project MPX, 2019-10-18 to 2019-12-20.

## Calendars

- Standard: Mon-Sun 08:00 am-12:00 pm, 01:00 pm-05:00 pm.

## Schedule

| ID | WBS | Task | Duration | Start | Finish | Predecessors | Complete | Text1 |
| --- | --- | --- | --- | --- | --- | --- | --- | --- |
| 1 | 1 | CHL1 Tests (Oportunistic RF On) | 3d | 2019-10-18 | 2019-10-20 |  | 100% | Done |
| 2 | 2 | Tunnel Open | 9d | 2019-10-21 | 2019-10-29 |  | 90% |  |
| 3 | 3 | **HCO** | 17d | 2019-10-18 | 2019-11-03 |  | 67% |  |
| 4 | 3.1 | DC Power Box supply Hipot | 1d | 2019-10-20 | 2019-10-20 |  | 100% | Done |
| 5 | 3.2 | Force Open C100 VBVs | 1d | 2019-10-22 | 2019-10-22 |  | 80% | Done |
| 6 | 3.3 | HCO | 17d | 2019-10-18 | 2019-11-03 |  | 65% |  |
| 7 | 4 | **Injector Setup** | 17d | 2019-10-18 | 2019-11-03 |  | 57% |  |
| 8 | 4.1 | Gun Electrode 130 keV tests | 3d | 2019-10-18 | 2019-10-20 |  | 100% | Done |
| 9 | 4.2 | Injector PSS certs w/ beam | 1d | 2019-10-21 | 2019-10-21 |  | 100% | Done |
| 10 | 4.3 | **FC1** | 6d | 2019-10-21 | 2019-10-26 | 8 | 84% |  |
| 11 | 4.3.1 | Cathode Alignment | 1d | 2019-10-22 | 2019-10-22 |  | 100% | Done |
| 12 | 4.3.2 | 4 Laser LLRF Phase Recovery | 1d | 2019-10-21 | 2019-10-21 |  | 100% | Done |
| 13 | 4.3.3 | Beam Setup (Inj Group) | 2d | 2019-10-21 | 2019-10-22 |  | 100% | Done |
| 14 | 4.3.4 | 130 keV Match | 1d | 2019-10-23 | 2019-10-23 |  | 60% | Done |
| 15 | 4.3.5 | Parity Settings for all 4 Lasers | 1d | 2019-10-24 | 2019-10-24 |  |  |  |
| 16 | 4.3.6 | 0L04 FE Test | 1d | 2019-10-24 | 2019-10-24 |  | 100% | Done |
| 17 | 4.3.7 | PQB Verification | 1d | 2019-10-26 | 2019-10-26 |  | 100% | Done |
| 18 | 4.3.8 | Reproducibility Studies | 1d | 2019-10-25 | 2019-10-25 |  | 100% | Done |
| 19 | 4.4 | **FC2** | 1d | 2019-10-27 | 2019-10-27 | 10 | 25% |  |
| 20 | 4.4.1 | Beam Setup (FCup 2) | 1d | 2019-10-27 | 2019-10-27 |  |  | Done |
| 21 | 4.4.2 | FCup#2 Centering (Current Discrepency Investigation) | 1d | 2019-10-27 | 2019-10-27 |  | 100% | Done |
| 22 | 4.4.3 | 6 MeV Region Match | 1d | 2019-10-27 | 2019-10-27 |  |  |  |
| 23 | 4.4.4 | PQB Setup Verification | 1d | 2019-10-27 | 2019-10-27 |  |  |  |
| 24 | 4.5 | **ILD** | 7d | 2019-10-28 | 2019-11-03 | 19 | 16% |  |
| 25 | 4.5.1 | Beam Setup (INJ Group) | 2d | 2019-10-28 | 2019-10-29 |  | 75% | Partially |
| 26 | 4.5.2 | Inj Matching (Chicane) | 1d | 2019-10-29 | 2019-10-29 |  |  |  |
| 27 | 4.5.3 | PQB Setup Verification | 1d | 2019-10-29 | 2019-10-29 |  |  |  |
| 28 | 4.5.4 | Other ILD Studies | 5d | 2019-10-30 | 2019-11-03 |  |  |  |
| 29 | 5 | SL RF On | 38d | 2019-10-18 | 2019-11-24 |  | 90% | Partially |
| 30 | 6 | NL@2K | 1d | 2019-10-24 | 2019-10-24 |  | 100% | Done |
| 31 | 7 | NL RF On | 37d | 2019-10-25 | 2019-11-30 | 30 | 20% | Partially |
| 32 | 8 | SRF Commisioning (NL Only) | 17d | 2019-10-18 | 2019-11-03 |  | 33% |  |
| 33 | 9 | C100 FE Measurement w/ GM Tubes | 1d | 2019-11-04 | 2019-11-04 |  |  |  |
| 34 | 10 | Set Energy (RF Push) | 1d | 2019-11-04 | 2019-11-04 | 32 |  |  |
| 35 | 11 | Box Supply Cycling RHEL-7 (Cade) | 1d | 2019-11-04 | 2019-11-04 |  |  |  |

Notes:
- 2: Tunnel open last open day will Monday 10/28 for 1L07 tuner cable work. RadCon Checklists have been comleted for Inj, NL, SL, and BSY.
- 4: October 17 - 20: DC Power got high potting completed and most shunt checks are finished. Punch list developed. Arc 10 string needs invesigation Arc 10 Work: https://logbooks.jlab.org/entry/3735720 Arc 10 String Fixed: MXPAA17 kixon circuit
- 5: All done except for 1L25 valves, which are new. http://devweb.acc.jlab.org/CSUEApps/atlis/task/19792
- 9: https://logbooks.jlab.org/entry/3735532
- 11: http://opsweb.acc.jlab.org/CSUEApps/atlis/task/18799
- 12: http://opsweb.acc.jlab.org/CSUEApps/atlis/task/19407 Results in: https://logbooks.jlab.org/entry/3735638
- 13: https://logbooks.jlab.org/entry/3735744 https://logbooks.jlab.org/entry/3737073
- 14: http://opsweb.acc.jlab.org/CSUEApps/atlis/task/19805
- 15: http://opsweb.acc.jlab.org/CSUEApps/atlis/task/19670
- 16: http://devweb.acc.jlab.org/CSUEApps/atlis/task/18979 / https://logbooks.jlab.org/entry/3737033 https://logbooks.jlab.org/entry/3737037
- 17: https://logbooks.jlab.org/entry/3737125
- 18: https://logbooks.jlab.org/entry/3737045 https://logbooks.jlab.org/entry/3737050
- 21: http://devweb.acc.jlab.org/CSUEApps/atlis/task/19617 https://logbooks.jlab.org/entry/3737012
- 22: http://opsweb.acc.jlab.org/CSUEApps/atlis/task/19786
- 23: http://opsweb.acc.jlab.org/CSUEApps/atlis/task/18793
- 25: https://logbooks.jlab.org/entry/3737280 https://logbooks.jlab.org/entry/3737286 https://logbooks.jlab.org/entry/3737540
- 27: http://opsweb.acc.jlab.org/CSUEApps/atlis/task/18793
- 29: October 18-20: Much of the C30s and C50s brought up. No C100s. https://logbooks.jlab.org/entry/3735406
- 31: Injector ZOnes and up to 1L17 have been turned on. Punch list in devolopment
- 32: October 18-20: 1L25 and 1L20 comissioning began. 1L20 entries: https://logbooks.jlab.org/entry/3735215 https://logbooks.jlab.org/entry/3735228 https://logbooks.jlab.org/entry/3735235 https://logbooks.jlab.org/entry/3735278 https://logbooks.jlab.org/entry/3735282 https://logbooks.jlab.org/entry/3735284 https://logbooks.jlab.org/entry/3735277 https://logbooks.jlab.org/entry/3737563 1L25 entries: https://logbooks.jlab.org/entry/3735349 https://logbooks.jlab.org/entry/3735417 https://logbooks.jlab.org/entry/3737066 https://logbooks.jlab.org/entry/3737194 https://logbooks.jlab.org/entry/3737257 https://logbooks.jlab.org/entry/3737493 https://logbooks.jlab.org/entry/3737518
- 33: Powers Atlis Inc
- 35: http://opsweb.acc.jlab.org/CSUEApps/atlis/atlis.php?load=Task&task_id=19184 / Can be done during RF Push, after DC Power HCO, and before 5 pass spin up

| ID | WBS | Task | Duration | Start | Finish | Predecessors |
| --- | --- | --- | --- | --- | --- | --- |
| 36 | 12 | **5 pass Spin up** | 7d | 2019-11-06 | 2019-11-12 | 34 |
| 37 | 12.1 | **Cold Startup** | 2d | 2019-11-06 | 2019-11-07 |  |
| 38 | 12.1.1 | Beam to 1R | 1d | 2019-11-06 | 2019-11-06 |  |
| 39 | 12.1.2 | Beam to 2R | 1d | 2019-11-07 | 2019-11-07 | 38 |
| 40 | 12.2 | **INJ / 1st pass Setup Tests** | 1d | 2019-11-08 | 2019-11-08 | 37 |
| 41 | 12.2.1 | NL / SL Drift Box Supply Calibration | 1d | 2019-11-08 | 2019-11-08 |  |
| 42 | 12.2.2 | Colinearity Checks | 1d | 2019-11-08 | 2019-11-08 |  |
| 43 | 12.2.3 | Bunch Compresssion using 0L04 | 1d | 2019-11-08 | 2019-11-08 |  |
| 44 | 12.2.4 | Ray Ttrace to 1R | 1d | 2019-11-08 | 2019-11-08 |  |
| 45 | 12.2.5 | Qualify Inj -> NL Match | 1d | 2019-11-08 | 2019-11-08 |  |
| 46 | 12.3 | **6 - ORFP ARC by ARC** | 4d | 2019-11-09 | 2019-11-12 | 40 |
| 47 | 12.3.1 | ARC4 | 1d | 2019-11-09 | 2019-11-09 |  |
| 48 | 12.3.2 | ARC7 | 1d | 2019-11-10 | 2019-11-10 | 47 |
| 49 | 12.3.3 | ARC9 | 1d | 2019-11-11 | 2019-11-11 | 48 |
| 50 | 12.3.4 | 5.5 ORFP Complete | 1d | 2019-11-12 | 2019-11-12 | 49 |
| 51 | 13 | **Beam Tests to Halls - Dates TBD** | 9d | 2019-11-13 | 2019-11-21 | 36 |
| 52 | 13.1 | RF Stress Test | 4d | 2019-11-13 | 2019-11-16 |  |
| 53 | 13.2 | Optimimizing BLM/RF/IC Faults | 1d | 2019-11-13 | 2019-11-13 |  |
| 54 | 13.3 | Spin Dance | 1d | 2019-11-15 | 2019-11-15 |  |
| 55 | 13.4 | Energy Adjustment + Spin Dance | 5d | 2019-11-13 | 2019-11-17 |  |
| 56 | 13.5 | Extraction & Match the Halls | 4d | 2019-11-18 | 2019-11-21 |  |
| 57 | 14 | **Ideas for BS - Dates TBD** | 7d | 2019-11-22 | 2019-11-28 | 51 |
| 58 | 14.1 | Machine Reproducibility After Wein Flips | 1d | 2019-11-22 | 2019-11-22 |  |
| 59 | 14.2 | SL Cryo/Electric Heat Balancing - Tief | 1d | 2019-11-22 | 2019-11-22 |  |
| 60 | 14.3 | C100-6R calibration | 1d | 2019-11-22 | 2019-11-22 |  |
| 61 | 14.4 | LEM Reproducibility | 1d | 2019-11-22 | 2019-11-22 |  |
| 62 | 14.5 | Beam Studies/ Collarbative Checks | 7d | 2019-11-22 | 2019-11-28 |  |
| 63 | 14.6 | Decarads installed 1L26-1S01 | 1d | 2019-11-22 | 2019-11-22 |  |

Notes:
- 37: Atlis Freeman & Aiken
- 38: Thread Beam Hand Phase Tune Energy Phaser
- 39: Thread through SL Hand Phase SL 2E Match SL Phaser
- 41: http://opsweb.acc.jlab.org/CSUEApps/atlis/task/18319 Yves to to identify contact (Still Doug Higinbotham?)
- 42: Position and timing colinearity for all 4 lasers. Check degree of colinearity through to 1R. Check 4 lasers vs. NL Gang phase. ATLis task needed?
- 43: Use Arc Bunch length measurment process to give max compression using 0L04 (minimum spot size in Arc 1 High dispersive region) at Max energy. Freeman to develop and ATLis task for this.
- 44: Tief / Yves
- 45: Step 1-4 in ORFP. Uses 1L02, 1L06, 1L10 viewers to qualify match from the Injector. Is there a better way? Try INJ FOpt correctors to FOpt to 1R?
- 52: Spin up 5 pass beam to Hall A. Optimize RF and Beam transport with 600 kW in the Machine. http://opsweb.acc.jlab.org/CSUEApps/atlis/task/19791
- 53: Perhaps needed to be done during RF stress testing. / May also require re-calibration of BLM? BLMs too sensitive? BLM setup procedure attached to: http://opsweb.acc.jlab.org/CSUEApps/atlis/task/16634
- 58: Rematching Early INJ Testing
- 60: Jay Atlis
- 61: Yves to Write ATLIs Checking Early NL Bypass
- 63: https://logbooks.jlab.org/entry/3737044 https://logbooks.jlab.org/entry/3736197

| ID | WBS | Task | Duration | Start | Finish |
| --- | --- | --- | --- | --- | --- |
| 64 | 15 | **Physics Start** | 26d | 2019-11-25 | 2019-12-20 |
| 65 | 15.1 | Hall A Physics | 19d | 2019-12-02 | 2019-12-20 |
| 66 | 15.2 | HB Physics | 26d | 2019-11-25 | 2019-12-20 |
| 67 | 15.3 | HC Physics | 26d | 2019-11-25 | 2019-12-20 |
| 68 | 15.4 | HD Physics | 26d | 2019-11-25 | 2019-12-20 |
